# Projekt_jo_02_03

Schedule from MS Project, 2008-08-01 to 2008-09-11, status date 2008-08-29, costs in Ft.
iqjb

## Calendars

- Szabványos: Mon-Fri 08:00-12:00, 13:00-17:00; Sat-Sun off.

## Resources

| Resource | Unit | Rate |
| --- | --- | --- |
| Á hálózatépítő 1 |  | 1500 |
| Á műszaki informatikus 1 |  | 1500 |
| Á adminisztrátor 1 |  | 1000 |
| Kovács Anita |  | 6000 |
| Kiss Attila |  | 10000 |
| Nagy Annamária |  | 1200 |
| Paál Anikó |  | 1300 |
| Kiss Anett |  | 800 |
| Rétlaki Géza |  | 1400 |
| Mároki Teréz |  | 1400 |
| Mosolygó Ferenc |  | 1600 |
| Téglás Csaba |  | 1200 |
| Podorek Paula |  | 800 |
| Tiefenghalter Eszter |  | 1200 |
| Szakócza István |  | 1700 |
| Késmárki Lilla |  | 1500 |
| Á hálózatépítő 2 |  | 1500 |
| Á műszaki informatikus 2 |  | 1500 |
| Á adminisztrátor 2 |  | 1000 |
| Á műszaki informatikus 3 |  | 1500 |
| Á adminisztrátor 3 |  | 1000 |
| Á adminisztrátor 4 |  | 1000 |
| Számítógép beszerzési költségek | eFt | 1000 |
| Hálózatépítés költségei | eFt | 1000 |
| Egyéb költségek | eFt | 1000 |
| Szoftverköltségek | eFt | 1000 |
| Á programozó 1 |  |  |
| Á programozó 2 |  |  |
| Á_projektmenedzser |  | 6000 |

## Schedule

| ID | WBS | Task | Type | Duration | Start | Finish | Predecessors | Total slack | Deadline | Resources | Work | Cost | Text29 | nap, óra |
| --- | --- | --- | --- | --- | --- | --- | --- | --- | --- | --- | --- | --- | --- | --- |
| 1 | 1 | **Célmeghatározás** |  | 6.5d | 2008-08-01 | 2008-08-11 |  | 0d |  |  | 32h | 2,336,000 | 480 | 6 n, 4 ó |
| 2 | 1.1 | hardverkövetelmény meghatározása |  | 4h | 2008-08-01 | 2008-08-01 |  | 0d |  | Á hálózatépítő 1; Á műszaki informatikus 1 | 8h | 12,000 | 480 | 4 ó |
| 3 | 1.2 | lehetséges beszállítók felkutatása, analizálása |  | 3d | 2008-08-01 | 2008-08-06 | 2 | 0d |  | Á adminisztrátor 1 | 24h | 24,000 | 480 | 3 n |
| 4 | 1.3 | beszállító kiválasztása | milestone | 0d | 2008-08-06 | 2008-08-06 | 3 | 0d |  | Á_projektmenedzser |  |  | 480 | --mérföldkő-- |
| 5 | 1.4 | hardver leszállítása | milestone | 3d | 2008-08-06 | 2008-08-11 | 4 | 0d |  | Számítógép beszerzési költségek [2300 eFt] |  | 2,300,000 | 480 | --mérföldkő-- |
| 6 | 2 | **Hálózatfejlesztés** |  | 7d | 2008-08-11 | 2008-08-20 |  | 0d |  |  | 88h | 120,000 | 480 | 7 n |
| 7 | 2.1 | szerver installálása |  | 3d | 2008-08-11 | 2008-08-14 | 5 | 0d |  | Á műszaki informatikus 1; Á műszaki informatikus 2 | 48h | 72,000 | 480 | 3 n |
| 8 | 2.2 | szerver konfigurálása |  | 1d | 2008-08-14 | 2008-08-15 | 7 | 0d |  | Á programozó 1 | 8h |  | 480 | 1 n |
| 9 | 2.3 | oktatóterem előkészítése |  | 2d | 2008-08-15 | 2008-08-19 | 8 | 0d |  | Á műszaki informatikus 1 | 16h | 24,000 | 480 | 2 n |
| 10 | 2.4 | oktatóterem előkészítése |  | 2d | 2008-08-15 | 2008-08-19 | 8 | 0d |  | Á műszaki informatikus 2 | 16h | 24,000 | 480 | 2 n |
| 11 | 2.5 | oktatóterem tesztelése |  | 1d | 2008-08-19 | 2008-08-20 | 9 | 0d |  |  |  |  | 480 | 1 n |
| 12 | 2.6 | oktatóterem tesztelése |  | 1d | 2008-08-19 | 2008-08-20 | 10 | 0d |  |  |  |  | 480 | 1 n |
| 13 | 2.7 | oktatótermek kész | milestone | 0d | 2008-08-20 | 2008-08-20 | 11, 12 | 0d | 2008-10-30 |  |  |  | 480 | --mérföldkő-- |
| 14 | 3 | Betanítás |  | 16d | 2008-08-20 | 2008-09-11 | 13 | 0d |  |  |  |  | 480 | 16 n |
